# Rotary Racer 9

Schedule from Planner, 2012-10-22 to 2013-04-29.

## Calendars

- Greenpower: Mon-Fri off; Sat-Sun as the base calendar. Exceptions (off unless hours are given): 2012-10-29, 2012-12-24, 2012-12-31, 2013-02-11.

## Schedule

| ID | WBS | Task | Type | Duration | Start | Finish | Predecessors | Constraint | Work |
| --- | --- | --- | --- | --- | --- | --- | --- | --- | --- |
| 1 | 1 | **Management** |  |  | 2012-10-22 | 2013-04-06 |  |  | 16h |
| 2 | 1.1 | Project Start |  |  | 2012-10-22 | 2012-10-22 |  |  | 8h |
| 3 | 1.2 | Meeting Start of project |  |  | 2012-10-22 | 2012-10-22 |  |  | 8h |
| 4 | 1.3 | First Race | milestone | 0d | 2013-04-08 | 2013-04-07 |  | must start on 2013-04-07 |  |
| 5 | 2 | **Car Design and build** |  |  | 2012-10-22 | 2013-04-29 |  |  | 312h |
| 6 | 2.1 | Body shape |  |  | 2012-10-22 | 2012-10-22 |  |  | 8h |
| 7 | 2.2 | Tube design |  |  | 2012-11-05 | 2012-11-05 | 6 |  | 8h |
| 8 | 2.3 | Build chassis |  |  | 2012-11-12 | 2012-11-26 | 7 |  | 24h |
| 9 | 2.4 | Rear subframe/Rollbar design |  |  | 2012-11-05 | 2012-11-12 |  | must start on 2012-10-29 | 16h |
| 10 | 2.5 | Rear subframe/Rollbar build |  |  | 2012-12-03 | 2012-12-17 | 8, 9 |  | 24h |
| 11 | 2.6 | Rear subframe/Rollbar fit |  |  | 2013-01-07 | 2013-01-14 | 8, 10 |  | 16h |
| 12 | 2.7 | Motor fit |  |  | 2013-01-21 | 2013-02-04 | 11 |  | 24h |
| 13 | 2.8 | Chain drive fitting |  |  | 2013-02-18 | 2013-02-25 | 12 |  | 16h |
| 14 | 2.9 | Steering Design |  |  | 2012-11-05 | 2012-11-12 |  | must start on 2012-10-29 | 16h |
| 15 | 2.10 | Steering Build |  |  | 2012-11-19 | 2012-12-10 | 14 |  | 32h |
| 16 | 2.11 | Steering fit |  |  | 2012-12-17 | 2013-01-14 | 15 |  | 24h |
| 17 | 2.12 | Chassis Fit together |  |  | 2013-03-04 | 2013-03-18 | 16, 13 |  | 24h |
| 18 | 2.13 | Top and Bottom attach |  |  | 2013-03-25 | 2013-04-01 | 17 |  | 16h |
| 19 | 2.14 | Seat make |  |  | 2012-10-22 | 2012-10-22 |  |  | 8h |
| 20 | 2.15 | Seat fit |  |  | 2013-03-25 | 2013-03-25 | 17, 19 |  | 8h |
| 21 | 2.16 | Battery mounting and boxes |  |  | 2013-03-25 | 2013-04-01 | 17 |  | 16h |
| 22 | 2.17 | Sides and behind head |  |  | 2013-04-08 | 2013-04-29 | 18 |  | 32h |
| 23 | 3 | **Electronics** |  |  | 2012-10-22 | 2013-04-01 |  |  | 48h |
| 24 | 3.1 | Speed controller Efficiency |  |  | 2012-10-22 | 2012-10-22 |  |  | 8h |
| 25 | 3.2 | Speed controller fix |  |  | 2012-10-22 | 2012-10-22 |  |  | 8h |
| 26 | 3.3 | Display Design |  |  | 2012-10-22 | 2012-10-22 |  |  | 8h |
| 27 | 3.4 | Display Build |  |  | 2012-10-22 | 2012-10-22 |  |  | 8h |
| 28 | 3.5 | Electronics Install |  |  | 2013-03-25 | 2013-04-01 | 17, 24 |  | 16h |
