# Rotary Racer 9

Schedule from Planner, 2012-10-22 to 2013-07-22.

## Calendars

- Greenpower: Mon-Fri off; Sat-Sun as the base calendar. Exceptions (off unless hours are given): 2012-10-29, 2012-12-24, 2012-12-31, 2013-02-11.

## Schedule

| ID | WBS | Task | Type | Duration | Start | Finish | Predecessors | Constraint | Work |
| --- | --- | --- | --- | --- | --- | --- | --- | --- | --- |
| 1 | 1 | **Management** |  |  | 2012-10-22 | 2013-06-08 |  |  | 24h |
| 2 | 1.1 | Project Start |  |  | 2012-10-22 | 2012-10-22 |  |  | 8h |
| 3 | 1.2 | Meeting Start of project |  |  | 2012-10-22 | 2012-10-22 |  |  | 8h |
| 4 | 1.3 | First Race | milestone | 0d | 2013-06-10 | 2013-06-09 |  | must start on 2013-06-09 |  |
| 5 | 1.4 | Where we are 1 |  |  | 2013-04-08 | 2013-04-08 |  | must start on 2013-04-08 | 8h |
| 6 | 2 | **Car Design and build** |  |  | 2012-10-22 | 2013-07-22 |  |  | 312h |
| 7 | 2.1 | Body shape |  |  | 2012-10-22 | 2012-10-22 |  |  | 8h |
| 8 | 2.2 | Tube design |  |  | 2012-11-05 | 2012-11-05 | 7 |  | 8h |
| 9 | 2.3 | Build chassis |  |  | 2012-11-12 | 2012-11-26 | 8 |  | 24h |
| 10 | 2.4 | Rear subframe/Rollbar design |  |  | 2012-11-05 | 2012-11-12 |  | must start on 2012-10-29 | 16h |
| 11 | 2.5 | Rear subframe/Rollbar build |  |  | 2012-12-03 | 2012-12-17 | 9, 10 |  | 24h |
| 12 | 2.6 | Rear subframe/Rollbar fit |  |  | 2013-04-15 | 2013-04-15 | 5, 9, 11 |  | 8h |
| 13 | 2.7 | Rear axle |  |  | 2012-10-22 | 2012-10-22 |  |  | 8h |
| 14 | 2.8 | Motor fit |  |  | 2013-04-22 | 2013-05-06 | 12 |  | 24h |
| 15 | 2.9 | Chain drive fitting |  |  | 2013-05-13 | 2013-05-20 | 14 |  | 16h |
| 16 | 2.10 | Steering Design |  |  | 2012-11-05 | 2012-11-12 |  | must start on 2012-10-29 | 16h |
| 17 | 2.11 | Steering Build |  |  | 2012-11-19 | 2012-12-10 | 16 |  | 32h |
| 18 | 2.12 | Steering fit |  |  | 2012-12-17 | 2013-01-14 | 17 |  | 24h |
| 19 | 2.13 | Chassis Fit together |  |  | 2013-05-27 | 2013-06-10 | 18, 15 |  | 24h |
| 20 | 2.14 | Top and Bottom attach |  |  | 2013-06-17 | 2013-06-24 | 19 |  | 16h |
| 21 | 2.15 | Seat make |  |  | 2012-10-22 | 2012-10-22 |  |  | 8h |
| 22 | 2.16 | Seat fit |  |  | 2013-06-17 | 2013-06-17 | 19, 21 |  | 8h |
| 23 | 2.17 | Battery mounting and boxes |  |  | 2013-06-17 | 2013-06-24 | 19 |  | 16h |
| 24 | 2.18 | Sides and behind head |  |  | 2013-07-01 | 2013-07-22 | 20 |  | 32h |

| ID | WBS | Task | Start | Finish | Predecessors | Work |
| --- | --- | --- | --- | --- | --- | --- |
| 25 | 3 | **Electronics** | 2012-10-22 | 2013-06-24 |  | 48h |
| 26 | 3.1 | Speed controller Efficiency | 2012-10-22 | 2012-10-22 |  | 8h |
| 27 | 3.2 | Speed controller fix | 2012-10-22 | 2012-10-22 |  | 8h |
| 28 | 3.3 | Display Design | 2012-10-22 | 2012-10-22 |  | 8h |
| 29 | 3.4 | Display Build | 2012-10-22 | 2012-10-22 |  | 8h |
| 30 | 3.5 | Electronics Install | 2013-06-17 | 2013-06-24 | 19, 26 | 16h |
